# Open data補助案_專案時程表

Schedule from MS Project, 2017-03-15 to 2018-09-17.

## Calendars

- 標準: Mon-Fri 08:00-12:00, 13:00-17:00; Sat-Sun off.

## Schedule

| ID | WBS | Task | Type | Duration | Start | Finish | Predecessors | Total slack |
| --- | --- | --- | --- | --- | --- | --- | --- | --- |
| 1 | 1 | **系統分析** |  | 73d | 2017-03-15 | 2017-06-23 |  | 0d |
| 2 | 1.1 | SA文件撰寫 | manual | 33d | 2017-03-15 | 2017-04-28 |  |  |
| 3 | 1.2 | SD文件撰寫 | manual | 33d | 2017-04-17 | 2017-05-31 |  |  |
| 4 | 1.3 | 資料表規劃 | manual | 50d | 2017-04-17 | 2017-06-23 |  |  |
| 5 | 2 | **資料收集** |  | 150d | 2017-04-03 | 2017-10-27 |  | 0d |
| 6 | 2.1 | 數據清整 | manual | 54d | 2017-04-03 | 2017-06-15 |  |  |
| 7 | 2.2 | **模型建立與實驗** |  | 96d | 2017-06-16 | 2017-10-27 |  |  |
| 8 | 2.2.1 | 會員畫像模型 | manual | 22d | 2017-06-16 | 2017-07-17 | 6 |  |
| 9 | 2.2.2 | 會員分群模型 | manual | 33d | 2017-07-18 | 2017-08-31 | 8 |  |
| 10 | 2.2.3 | 旅遊景點推薦模型 | manual | 41d | 2017-09-01 | 2017-10-27 | 9 |  |
| 11 | 2.2.4 | 文本分析模型 | manual | 37d | 2017-06-16 | 2017-08-07 | 6 |  |
| 12 | 3 | **TRIZ設計** |  | 61d | 2017-07-14 | 2017-10-06 |  | 0d |
| 13 | 3.1 | 設計50組創新行程 | manual | 26d | 2017-07-14 | 2017-08-18 |  |  |
| 14 | 3.2 | 進行問卷設計 | manual | 32d | 2017-07-24 | 2017-09-05 |  |  |
| 15 | 3.3 | 產出20組創新行程 | manual | 26d | 2017-09-01 | 2017-10-06 |  |  |
| 16 | 4 | **程式開發** |  | 295d | 2017-08-01 | 2018-09-17 |  | 0d |
| 17 | 4.1 | 旅遊輿論爬蟲與監控開發 | manual | 23d | 2017-08-01 | 2017-08-31 |  |  |
| 18 | 4.2 | 分析結果匯入程式 | manual | 62d | 2018-06-23 | 2018-09-17 |  |  |
| 19 | 4.3 | 分析模組 | manual | 60d | 2017-08-01 | 2017-10-23 |  |  |
| 20 | 4.4 | 系統測試及上線 | manual | 21d | 2017-10-09 | 2017-11-06 |  |  |
